# ejemplo1

Schedule from MS Project, 2005-11-14 to 2006-03-10, status date 2005-02-09, costs in pta.
_

## Calendars

- Estándar: Mon-Fri 08:00-12:00, 13:00-17:00; Sat-Sun off.
- Calendario de clase: Mon off; Tue 16:30-19:10; Wed off; Thu 17:25-20:20; Fri 16:20-20:20; Sat-Sun off.
- Calendario de trabajo: Mon 10:00-12:00; Tue 10:00-12:00, 16:30-19:10; Wed 10:00-12:00; Thu 10:00-12:00, 16:25-20:20; Fri 10:00-12:00, 18:20-20:20; Sat-Sun off.

## Resources

| Resource | Rate |
| --- | --- |
| laboratorio de diseño |  |
| laboratorio instrumentación |  |
| laboratorio de prototipos |  |
| técnico en desarrollo de productos electrónicos | 3000 |

## Schedule

| ID | WBS | Task | Duration | Start | Finish | Predecessors | Baseline start | Baseline finish | Baseline duration | Total slack | Free slack | Constraint | Calendar | Resources | Work | Cost | Baseline cost |
| --- | --- | --- | --- | --- | --- | --- | --- | --- | --- | --- | --- | --- | --- | --- | --- | --- | --- |
| 1 | 1 | **estudio de la tecnología** | 4.06d | 2005-11-14 | 2005-11-18 |  | 2005-11-14 | 2005-11-18 | 4.06d | 1d |  |  |  |  | 37h | 111,000 | 111,000 |
| 2 | 1.1 | Estudio del bus PCI | 12h | 2005-11-14 | 2005-11-17 |  | 2005-11-14 | 2005-11-17 | 12h | 0.5d | 0d |  | Calendario de trabajo | técnico en desarrollo de productos electrónicos | 12h | 36,000 | 36,000 |
| 3 | 1.2 | Estudio del 8255 | 3h | 2005-11-14 | 2005-11-15 |  | 2005-11-14 | 2005-11-15 | 3h | 1.64d |  |  | Calendario de trabajo | técnico en desarrollo de productos electrónicos | 3h | 9,000 | 9,000 |
| 4 | 1.3 | Estudio del 8254 | 3h | 2005-11-15 | 2005-11-15 |  | 2005-11-15 | 2005-11-15 | 3h | 1.26d |  |  | Calendario de trabajo | técnico en desarrollo de productos electrónicos | 3h | 9,000 | 9,000 |
| 5 | 1.4 | Estudio de los recursos del PC: IRQ y DMA | 10h | 2005-11-14 | 2005-11-17 |  | 2005-11-14 | 2005-11-17 | 10h | 0.75d | 0.58d |  | Calendario de trabajo | técnico en desarrollo de productos electrónicos | 10h | 30,000 | 30,000 |
| 6 | 1.5 | recopilacion de información | 3h | 2005-11-17 | 2005-11-18 | 2, 3, 4, 5 | 2005-11-17 | 2005-11-18 | 3h | 0.5d | 0d |  | Calendario de trabajo | técnico en desarrollo de productos electrónicos [300%] | 9h | 27,000 | 27,000 |
| 7 | 2 | **estudio de altenativas** | 4.69d | 2005-11-18 | 2005-11-24 |  | 2005-11-18 | 2005-11-25 | 5.69d | 2.5d |  |  |  |  | 38h | 114,000 | 114,000 |
| 8 | 2.1 | uso de circuito discretos | 16h | 2005-11-18 | 2005-11-24 | 6 | 2005-11-18 | 2005-11-25 | 16h | 1d | 0d |  | Calendario de trabajo | técnico en desarrollo de productos electrónicos | 16h | 48,000 | 48,000 |
| 9 | 2.2 | uso de circuitos programables | 16h | 2005-11-18 | 2005-11-24 | 6 | 2005-11-18 | 2005-11-25 | 16h | 1d | 0d |  | Calendario de trabajo | técnico en desarrollo de productos electrónicos | 16h | 48,000 | 48,000 |
| 10 | 2.3 | conclusiones y decisión | 2h | 2005-11-24 | 2005-11-24 | 8, 9 | 2005-11-25 | 2005-11-25 | 2h | 1d |  |  | Calendario de trabajo | técnico en desarrollo de productos electrónicos [300%] | 6h | 18,000 | 18,000 |
| 11 | 3 | **definición de interfaces** | 5.69d | 2005-11-18 | 2005-11-25 |  | 2005-11-18 | 2005-11-23 | 3.17d | 1.5d |  |  |  |  | 20h | 60,000 | 60,000 |
| 12 | 3.1 | definición del interfaz externo | 4h | 2005-11-21 | 2005-11-22 | 14 | 2005-11-21 | 2005-11-22 | 4h | 1.76d | 0d |  | Calendario de trabajo | técnico en desarrollo de productos electrónicos | 4h | 12,000 | 12,000 |
| 13 | 3.2 | definición del interfaz interno | 4h | 2005-11-23 | 2005-11-24 | 14 | 2005-11-22 | 2005-11-23 | 4h | 1.25d |  |  | Calendario de trabajo | técnico en desarrollo de productos electrónicos | 4h | 12,000 | 12,000 |
| 14 | 3.3 | definición del interfaz lógico | 4h | 2005-11-18 | 2005-11-21 | 6 | 2005-11-18 | 2005-11-21 | 4h | 1.75d | 0d |  | Calendario de trabajo | técnico en desarrollo de productos electrónicos | 4h | 12,000 | 12,000 |
| 15 | 3.4 | definición del cable de pruebas | 4h | 2005-11-22 | 2005-11-23 | 12 | 2005-11-22 | 2005-11-23 | 4h | 1.76d | 0d |  | Calendario de trabajo | técnico en desarrollo de productos electrónicos | 4h | 12,000 | 12,000 |
| 16 | 3.5 | definición del interfaz software | 4h | 2005-11-25 | 2005-11-25 | 6 | 2005-11-22 | 2005-11-23 | 4h | 0.5d |  |  | Calendario de trabajo | técnico en desarrollo de productos electrónicos | 4h | 12,000 | 12,000 |
| 17 | 4 | realización del cable de pruebas | 1h | 2005-11-25 | 2005-11-25 | 15 | 2005-12-07 | 2005-12-16 | 1h | 35.12d |  |  | Calendario de trabajo | laboratorio instrumentación; técnico en desarrollo de productos electrónicos | 1h | 3,000 | 3,000 |
| 18 | 5 | **realización del software** | 35.06d | 2005-11-29 | 2006-01-17 |  | 2005-11-23 | 2005-12-16 | 16.83d | 27.06d |  |  |  |  | 111h | 333,000 | 333,000 |
| 19 | 5.1 | **software de comprobación bajo DOS** | 5.06d | 2005-11-29 | 2005-12-06 | 16 | 2005-11-23 | 2005-11-29 | 4.52d | 27.06d | 0d |  |  |  | 17h | 51,000 | 51,000 |
| 20 | 5.1.1 | rutinas de comprobación de los puertos | 2h | 2005-11-29 | 2005-11-29 |  | 2005-11-23 | 2005-11-24 | 2h | 6.5d |  |  | Calendario de clase | técnico en desarrollo de productos electrónicos; laboratorio de diseño | 2h | 6,000 | 6,000 |
| 21 | 5.1.2 | rutinas de comprobación de las E/S analógicas | 3h | 2005-11-29 | 2005-12-01 |  | 2005-11-24 | 2005-11-25 | 3h | 9.62d |  |  | Calendario de clase | laboratorio de diseño; técnico en desarrollo de productos electrónicos | 3h | 9,000 | 9,000 |
| 22 | 5.1.3 | rutinas de comprobación de las interrupciones | 4h | 2005-12-01 | 2005-12-06 |  | 2005-11-25 | 2005-11-29 | 4h | 10.88d |  |  | Calendario de clase | laboratorio de diseño; técnico en desarrollo de productos electrónicos | 4h | 12,000 | 12,000 |
| 23 | 5.1.4 | rutinas de comprobación de los temporizadores | 2h | 2005-11-29 | 2005-11-29 |  | 2005-11-24 | 2005-11-24 | 2h | 8.75d |  |  | Calendario de clase | laboratorio de diseño; técnico en desarrollo de productos electrónicos | 2h | 6,000 | 6,000 |
| 24 | 5.1.5 | rutinas de comprobación del acceso por DMA | 6h | 2005-11-29 | 2005-12-06 |  | 2005-11-28 | 2005-11-29 | 6h | 11d |  |  | Calendario de clase | laboratorio de diseño; técnico en desarrollo de productos electrónicos | 6h | 18,000 | 18,000 |
| 25 | 5.2 | software de comprobación bajo Windows | 14h | 2005-12-06 | 2005-12-20 | 19 | 2005-11-29 | 2005-12-05 | 14h | 14.25d |  |  | Calendario de clase | laboratorio de diseño; técnico en desarrollo de productos electrónicos | 14h | 42,000 | 42,000 |
| 26 | 5.3 | software de comprobación bajo Linux | 20h | 2005-12-06 | 2005-12-23 | 19 | 2005-11-29 | 2005-12-07 | 20h | 13.25d |  | start no earlier than 2005-02-09 | Calendario de clase | laboratorio de diseño; técnico en desarrollo de productos electrónicos | 20h | 60,000 | 60,000 |
| 27 | 5.4 | realización de drivers para windows | 30h | 2005-12-06 | 2006-01-17 | 16 | 2005-11-29 | 2005-12-15 | 30h | 8.96d |  | start no earlier than 2005-02-09 | Calendario de clase | laboratorio de diseño; técnico en desarrollo de productos electrónicos | 30h | 90,000 | 90,000 |
| 28 | 5.5 | realización de driver para linux | 30h | 2005-12-08 | 2006-01-17 | 16 | 2005-12-06 | 2005-12-16 | 30h | 9.18d |  |  | Calendario de clase | laboratorio de diseño; técnico en desarrollo de productos electrónicos | 30h | 90,000 | 90,000 |

| ID | WBS | Task | Duration | Start | Finish | Predecessors | Baseline start | Baseline finish | Baseline duration | Total slack | Free slack | Calendar | Resources | Work | Cost | Baseline cost |
| --- | --- | --- | --- | --- | --- | --- | --- | --- | --- | --- | --- | --- | --- | --- | --- | --- |
| 29 | 6 | **realización del hardware** | 73.06d | 2005-11-29 | 2006-03-10 | 7, 11 | 2005-11-28 | 2006-01-10 | 31.75d | 0d |  |  |  | 128h | 384,000 | 384,000 |
| 30 | 6.1 | **prototipo wrapping** | 60.06d | 2005-11-29 | 2006-02-21 |  | 2005-11-28 | 2006-01-02 | 25.06d | 0d |  |  |  | 97h | 291,000 | 291,000 |
| 31 | 6.1.1 | diseño del sistema | 40h | 2005-11-29 | 2006-01-03 |  | 2005-11-28 | 2005-12-13 | 40h | 0d |  | Calendario de clase | laboratorio de diseño; técnico en desarrollo de productos electrónicos | 40h | 120,000 | 120,000 |
| 32 | 6.1.2 | montaje del sistema de control | 4h | 2006-01-17 | 2006-01-19 | 34 | 2005-12-16 | 2005-12-20 | 4h | 5.62d |  | Calendario de clase | técnico en desarrollo de productos electrónicos | 4h | 12,000 | 12,000 |
| 33 | 6.1.3 | montaje del bloque de puertos | 4h | 2006-01-03 | 2006-01-06 | 31 | 2005-12-13 | 2005-12-14 | 4h | 0d |  | Calendario de clase | laboratorio instrumentación; técnico en desarrollo de productos electrónicos | 4h | 12,000 | 12,000 |
| 34 | 6.1.4 | prueba el bloque de puertos | 10h | 2006-01-06 | 2006-01-17 | 33, 20 | 2005-12-14 | 2005-12-16 | 10h | 0d |  | Calendario de clase | laboratorio instrumentación; técnico en desarrollo de productos electrónicos | 10h | 30,000 | 30,000 |
| 35 | 6.1.5 | montaje del bloque temporizador | 4h | 2006-01-17 | 2006-01-19 | 34 | 2005-12-16 | 2005-12-20 | 4h | 0d |  | Calendario de clase | laboratorio instrumentación; técnico en desarrollo de productos electrónicos | 4h | 12,000 | 12,000 |
| 36 | 6.1.6 | prueba del bloque temporizador | 4h | 2006-01-19 | 2006-01-24 | 35, 23 | 2005-12-20 | 2005-12-20 | 4h | 0d |  | Calendario de clase | laboratorio instrumentación; técnico en desarrollo de productos electrónicos | 4h | 12,000 | 12,000 |
| 37 | 6.1.7 | montaje del bloque ADC | 4h | 2006-01-24 | 2006-01-26 | 36 | 2005-12-20 | 2005-12-22 | 4h | 0d |  | Calendario de clase | laboratorio instrumentación; técnico en desarrollo de productos electrónicos | 4h | 12,000 | 12,000 |
| 38 | 6.1.8 | prueba del bloque ADC | 10h | 2006-01-26 | 2006-02-07 | 21, 37 | 2005-12-22 | 2005-12-26 | 10h | 0d |  | Calendario de clase | laboratorio instrumentación; técnico en desarrollo de productos electrónicos | 10h | 30,000 | 30,000 |
| 39 | 6.1.9 | montaje del bloque IRQ y DMA | 2h | 2006-02-07 | 2006-02-07 | 38 | 2005-12-27 | 2005-12-27 | 2h | 0d |  | Calendario de clase | laboratorio instrumentación; técnico en desarrollo de productos electrónicos | 2h | 6,000 | 6,000 |
| 40 | 6.1.10 | prueba del bloque IRQ y DMA | 15h | 2006-02-07 | 2006-02-21 | 24, 22, 39 | 2005-12-27 | 2006-01-02 | 15h | 0d |  | Calendario de clase | laboratorio instrumentación; técnico en desarrollo de productos electrónicos | 15h | 45,000 | 45,000 |
| 41 | 6.2 | **realización del circuito definitivo** | 13d | 2006-02-21 | 2006-03-10 | 30 | 2006-01-02 | 2006-01-10 | 6.69d | 0d |  |  |  | 31h | 93,000 | 93,000 |
| 42 | 6.2.1 | realización del PCB | 10h | 2006-02-21 | 2006-03-02 |  | 2006-01-02 | 2006-01-05 | 10h | 0d |  | Calendario de clase | laboratorio de prototipos; laboratorio de diseño; técnico en desarrollo de productos electrónicos | 10h | 30,000 | 30,000 |
| 43 | 6.2.2 | comprobación de la placa | 10h | 2006-03-02 | 2006-03-10 | 42 | 2006-01-05 | 2006-01-10 | 10h | 0d |  | Calendario de clase | laboratorio de diseño; laboratorio de prototipos; técnico en desarrollo de productos electrónicos; laboratorio instrumentación | 10h | 30,000 | 30,000 |
| 44 | 6.2.3 | motaje de componentes | 3h | 2006-02-21 | 2006-02-23 | 13 | 2006-01-02 | 2006-01-03 | 3h | 0.85d | 0d | Calendario de clase | laboratorio instrumentación; técnico en desarrollo de productos electrónicos | 3h | 9,000 | 9,000 |
| 45 | 6.2.4 | prueba de la placa | 8h | 2006-02-23 | 2006-03-02 | 44 | 2006-01-03 | 2006-01-05 | 8h | 0.85d | 0d | Calendario de clase | laboratorio instrumentación; técnico en desarrollo de productos electrónicos | 8h | 24,000 | 24,000 |
| 46 | 7 | **realización de la documentación** | 3.38d | 2006-03-02 | 2006-03-08 | 45 | 2006-01-05 | 2006-01-10 | 3d | 2.62d |  |  |  | 29h | 87,000 | 87,000 |
| 47 | 7.1 | realización de la memoria descriptiva | 8h | 2006-03-03 | 2006-03-08 | 52 | 2006-01-06 | 2006-01-10 | 8h | 1.36d |  | Calendario de trabajo | técnico en desarrollo de productos electrónicos | 8h | 24,000 | 24,000 |
| 48 | 7.2 | recopilación de la documentoación del diseño del hardware | 8h | 2006-03-02 | 2006-03-07 |  | 2006-01-05 | 2006-01-09 | 8h | 1.74d |  | Calendario de trabajo | técnico en desarrollo de productos electrónicos | 8h | 24,000 | 24,000 |
| 49 | 7.3 | recopilación de la documentación de diseño de software | 4h | 2006-03-03 | 2006-03-06 |  | 2006-01-05 | 2006-01-06 | 4h | 1.98d |  | Calendario de trabajo | técnico en desarrollo de productos electrónicos | 4h | 12,000 | 12,000 |
| 50 | 7.4 | recopilación de los planos | 1h | 2006-03-07 | 2006-03-08 |  | 2006-01-10 | 2006-01-10 | 1h | 1.38d |  | Calendario de trabajo | técnico en desarrollo de productos electrónicos | 1h | 3,000 | 3,000 |
| 51 | 7.5 | realización del presupuesto | 1h | 2006-03-08 | 2006-03-08 |  | 2006-01-10 | 2006-01-10 | 1h | 1.27d |  | Calendario de trabajo | técnico en desarrollo de productos electrónicos | 1h | 3,000 | 3,000 |
| 52 | 7.6 | realización del manual de usuario | 3h | 2006-03-02 | 2006-03-03 |  | 2006-01-05 | 2006-01-05 | 3h | 1.36d | 0d | Calendario de trabajo | técnico en desarrollo de productos electrónicos | 3h | 9,000 | 9,000 |
| 53 | 7.7 | realización del manual del servicio técnico | 4h | 2006-03-07 | 2006-03-07 |  | 2006-01-09 | 2006-01-10 | 4h | 1.48d |  | Calendario de trabajo | técnico en desarrollo de productos electrónicos | 4h | 12,000 | 12,000 |
