# proyecto1-modificado

Schedule from MS Project, 2013-09-18 to 2013-11-29.
_

## Calendars

- Estándar: Mon 19:30-22:00; Tue off; Wed 18:20-20:20; Thu off; Fri 16:30-19:10; Sat 10:00-11:00; Sun off.
- Calendario de clase: Mon off; Tue 19:30-22:00; Wed 18:20-20:20; Thu off; Fri 16:30-19:10; Sat-Sun off. Exceptions (off unless hours are given): 2013-10-25, 2013-11-01.
- Calendario de trabajo: Mon 19:30-22:00; Tue 10:00-12:00; Wed 16:20-20:20; Thu 10:00-12:00; Fri 16:30-19:10; Sat 10:00-14:00; Sun off. Exceptions (off unless hours are given): 2013-10-25, 2013-11-01.

## Resources

| Resource |
| --- |
| profesor |
| técnico DPE |
| laboratorio |

## Schedule

| ID | WBS | Task | Duration | Start | Finish | Predecessors | Total slack | Free slack | Calendar | Resources | Work |
| --- | --- | --- | --- | --- | --- | --- | --- | --- | --- | --- | --- |
| 1 | 1 | presentación | 2h | 2013-09-18 | 2013-09-18 |  | 0.27d | 0d | Calendario de clase | profesor; laboratorio | 2h |
| 2 | 2 | **estudios previos** | 2.94d | 2013-09-20 | 2013-10-09 |  | 0.27d |  |  |  | 32.5h |
| 3 | 2.1 | Repaso del PIC16F84 | 3h | 2013-09-20 | 2013-09-24 | 1 | 0.27d | 0d | Calendario de clase | profesor | 3h |
| 4 | 2.2 | Repaso del PIC16F88 | 8h | 2013-09-24 | 2013-10-02 | 3 | 0d |  | Calendario de clase | profesor; técnico DPE [80%] | 10.5h |
| 5 | 2.3 | Estudio arquitectura enhanced | 3h | 2013-10-02 | 2013-10-04 | 4 | 0d |  | Calendario de clase | profesor | 3h |
| 6 | 2.4 | estudio dsPIC | 3h | 2013-10-04 | 2013-10-08 | 5 | 0d |  | Calendario de clase | profesor | 3h |
| 7 | 2.5 | Busqueda documentacion sobre robots | 7h | 2013-09-25 | 2013-09-27 | 3 | 18.69d |  | Calendario de trabajo | técnico DPE | 7h |
| 8 | 2.6 | Estudio de sensores y motores | 3h | 2013-10-09 | 2013-10-09 | 6, 5 | 0.08d | 0d | Calendario de trabajo | técnico DPE | 3h |
| 9 | 2.7 | Elección del modelo de robot y realización del anteproyecto | 3h | 2013-10-09 | 2013-10-09 | 6, 5 | 0.08d | 0d | Calendario de trabajo | técnico DPE | 3h |
| 10 | 3 | **realización de la carrocería** | 7.44d | 2013-10-09 | 2013-11-29 | 9 | 0d |  |  |  | 15h |
| 11 | 3.1 | Realización de la carroceria con la impresora 3D | 5h | 2013-10-09 | 2013-10-11 | 9 | 10.08d | 0d | Calendario de trabajo | técnico DPE | 5h |
| 12 | 3.2 | Montaje de la carrocería, ruedas y motores | 1h | 2013-10-11 | 2013-10-12 | 11 | 10.08d | 0d | Calendario de trabajo | técnico DPE | 1h |
| 13 | 3.3 | Montaje de la placa de sensores | 1h | 2013-10-18 | 2013-10-18 | 20 | 8.52d | 0d | Calendario de trabajo | técnico DPE | 1h |
| 14 | 3.4 | Montaje con el prototipo hardware | 1h | 2013-10-18 | 2013-10-18 | 21, 11, 12, 13 | 8.52d | 0.17d | Calendario de trabajo | técnico DPE | 1h |
| 15 | 3.5 | Montaje de la placa PCB | 1h | 2013-11-21 | 2013-11-21 | 27 | 0.12d | 0d | Calendario de trabajo | técnico DPE | 1h |
| 16 | 3.6 | Pruebas globales | 6h | 2013-11-22 | 2013-11-29 | 15, 33 | 0d |  | Calendario de clase | técnico DPE; laboratorio | 6h |
| 17 | 4 | **realización del hardware** | 6.25d | 2013-10-09 | 2013-11-20 | 9 | 0d |  |  |  | 32h |
| 18 | 4.1 | prueba de sensores | 3h | 2013-10-09 | 2013-10-11 | 8 | 0.08d | 0d | Calendario de clase | técnico DPE; laboratorio | 3h |
| 19 | 4.2 | prueba de motores | 1h | 2013-10-09 | 2013-10-09 | 8 | 0.33d | 0d | Calendario de clase | técnico DPE; laboratorio | 1h |
| 20 | 4.3 | realización de la placa de sensores | 3h | 2013-10-11 | 2013-10-18 | 18 | 3.21d | 0d | Calendario de clase | técnico DPE; laboratorio | 3h |
| 21 | 4.4 | realización del prototipo en wrapping | 5h | 2013-10-11 | 2013-10-14 | 18, 19, 9 | 0.77d | 0.27d | Calendario de trabajo | técnico DPE | 5h |
| 22 | 4.5 | pruebas de Hardware y modificaciones | 12h | 2013-10-16 | 2013-11-08 | 21 | 0d |  | Calendario de clase | técnico DPE; laboratorio | 12h |
| 23 | 4.6 | **realización del circuito impreso** | 1.88d | 2013-11-08 | 2013-11-20 |  | 0d |  |  |  | 8h |
| 24 | 4.6.1 | diseño de la placa | 4h | 2013-11-08 | 2013-11-15 | 22 | 0d |  | Calendario de clase | técnico DPE | 4h |
| 25 | 4.6.2 | realización de la placa | 2h | 2013-11-15 | 2013-11-15 | 24 | 0d |  | Calendario de clase | técnico DPE; laboratorio | 2h |
| 26 | 4.6.3 | comprobación de la placa | 1h | 2013-11-20 | 2013-11-20 | 25 | 0d |  | Calendario de clase | técnico DPE; laboratorio | 1h |
| 27 | 4.6.4 | montaje de componentes | 1h | 2013-11-20 | 2013-11-20 | 26 | 0d |  | Calendario de clase | técnico DPE; laboratorio | 1h |

| ID | WBS | Task | Duration | Start | Finish | Predecessors | Total slack | Free slack | Calendar | Resources | Work |
| --- | --- | --- | --- | --- | --- | --- | --- | --- | --- | --- | --- |
| 28 | 5 | **realización del software** | 1.94d | 2013-10-10 | 2013-10-23 |  | 4.19d |  |  |  | 24h |
| 29 | 5.1 | rutinas de prueba de sensores | 3h | 2013-10-11 | 2013-10-12 | 8, 6, 18 | 9.83d | 0.6d | Calendario de trabajo | técnico DPE | 3h |
| 30 | 5.2 | rutinas de prueba de motores | 3h | 2013-10-10 | 2013-10-11 | 8, 6, 19 | 10.33d | 0.25d | Calendario de trabajo | técnico DPE | 3h |
| 31 | 5.3 | rutinas de lectura de sensores | 4h | 2013-10-18 | 2013-10-19 | 20, 29 | 8.27d | 0d | Calendario de trabajo | técnico DPE | 4h |
| 32 | 5.4 | rutinas de movimiento de motores | 4h | 2013-10-12 | 2013-10-14 | 12, 30 | 10.08d | 0.98d | Calendario de trabajo | técnico DPE | 4h |
| 33 | 5.5 | movimiento del robot | 10h | 2013-10-19 | 2013-10-23 | 31, 32, 21, 14 | 8.27d | 4.19d | Calendario de trabajo | técnico DPE | 10h |
| 34 | 6 | **realización de la documentación** | 0.94d | 2013-11-15 | 2013-11-21 |  | 1.19d |  |  |  | 18h |
| 35 | 6.1 | memoria descriptiva | 6h | 2013-11-15 | 2013-11-16 | 24 | 2.38d | 0d | Calendario de trabajo | técnico DPE | 6h |
| 36 | 6.2 | diseño de hardware | 4h | 2013-11-18 | 2013-11-19 | 35 | 2.38d | 0d | Calendario de trabajo | técnico DPE | 4h |
| 37 | 6.3 | diseño de software | 4h | 2013-11-19 | 2013-11-20 | 36 | 2.38d | 0d | Calendario de trabajo | técnico DPE | 4h |
| 38 | 6.4 | planos | 1h | 2013-11-19 | 2013-11-20 | 36 | 3d |  | Calendario de trabajo | técnico DPE | 1h |
| 39 | 6.5 | presupuesto | 1h | 2013-11-20 | 2013-11-21 | 36, 37 | 2.5d |  | Calendario de trabajo | técnico DPE | 1h |
| 40 | 6.6 | manual del S.A.T. | 2h | 2013-11-20 | 2013-11-21 | 36, 37 | 2.38d |  | Calendario de trabajo | técnico DPE | 2h |
